# IMETAME PROJECT

Schedule from MS Project, 2020-10-26 to 2020-12-21, status date 2020-10-20.

## Calendars

- Padrão: Mon-Fri 09:00-12:00, 13:00-18:00; Sat-Sun off.

## Schedule

| ID | WBS | Task | Type | Duration | Start | Finish | Predecessors | Baseline start | Baseline finish | Baseline duration | Total slack |
| --- | --- | --- | --- | --- | --- | --- | --- | --- | --- | --- | --- |
| 1 | 1 | **Fase Inicial (30 dias)** |  | 36d | 2020-10-26 | 2020-12-14 |  | 2020-10-26 | 2020-12-14 | 36d | 0d |
| 2 | 1.1 | **Estudo Planialtimétrico** |  | 4d | 2020-10-26 | 2020-10-29 |  | 2020-10-26 | 2020-10-29 | 4d | 0d |
| 3 | 1.1.1 | Sistema de coordenadas | manual | 1d | 2020-10-26 | 2020-10-26 |  | 2020-10-26 | 2020-10-26 | 1d |  |
| 4 | 1.1.2 | Divisa de Fusos | manual | 1d | 2020-10-26 | 2020-10-26 |  | 2020-10-26 | 2020-10-26 | 1d |  |
| 5 | 1.1.3 | Altimetria | manual | 3d | 2020-10-27 | 2020-10-29 |  | 2020-10-27 | 2020-10-29 | 3d |  |
| 6 | 1.1.4 | Planimetria | manual | 3d | 2020-10-27 | 2020-10-29 |  | 2020-10-27 | 2020-10-29 | 3d |  |
| 7 | 1.2 | Estudos Geológicos | manual | 5d | 2020-10-26 | 2020-10-30 |  | 2020-10-26 | 2020-10-30 | 5d |  |
| 8 | 1.3 | Estudos Hidrológicos | manual | 5d | 2020-10-26 | 2020-10-30 |  | 2020-10-26 | 2020-10-30 | 5d |  |
| 9 | 1.4 | **Estudo de traçado** |  | 36d | 2020-10-26 | 2020-12-14 |  | 2020-10-26 | 2020-12-14 | 36d | 0d |
| 10 | 1.4.1 | Parâmetros de Projeto | manual | 1d | 2020-10-26 | 2020-10-26 |  | 2020-10-26 | 2020-10-26 | 1d |  |
| 11 | 1.4.2 | Alternativas de traçados | manual | 35d | 2020-10-27 | 2020-12-14 |  | 2020-10-27 | 2020-12-14 | 35d |  |
| 12 | 2 | **Fase Final - Entrega Final (60 dias)** |  | 41d | 2020-10-26 | 2020-12-21 |  | 2020-10-26 | 2020-12-21 | 41d | 0d |
| 13 | 2.1 | Descrição técnica do traçado | manual | 5d | 2020-12-15 | 2020-12-21 | 11 | 2020-12-15 | 2020-12-21 | 5d |  |
| 14 | 2.2 | Cartografia e geoprocessamento | manual | 35d | 2020-10-27 | 2020-12-14 |  | 2020-10-27 | 2020-12-14 | 35d |  |
| 15 | 2.3 | Geologia e Geotécnica | manual | 4d | 2020-10-27 | 2020-10-30 |  | 2020-10-27 | 2020-10-30 | 4d |  |
| 16 | 2.4 | **Terraplenagem** |  | 36d | 2020-10-26 | 2020-12-14 |  | 2020-10-26 | 2020-12-14 | 36d | 0d |
| 17 | 2.4.1 | Inclinação dos taludes e banqueamento | manual | 1d | 2020-10-26 | 2020-10-26 |  | 2020-10-26 | 2020-10-26 | 1d |  |
| 18 | 2.4.2 | Fator de homogeneização | manual | 35d | 2020-10-27 | 2020-12-14 |  | 2020-10-27 | 2020-12-14 | 35d |  |
| 19 | 2.4.3 | Metodologia Utilizada | manual | 5d | 2020-10-27 | 2020-11-02 |  | 2020-10-27 | 2020-11-02 | 5d |  |
| 20 | 2.5 | **Anteprojeto Geométrico** |  | 40d | 2020-10-26 | 2020-12-18 |  | 2020-10-26 | 2020-12-18 | 40d | 0d |
| 21 | 2.5.1 | Planta | manual | 40d | 2020-10-26 | 2020-12-18 |  | 2020-10-26 | 2020-12-18 | 40d |  |
| 22 | 2.5.2 | Perfil | manual | 40d | 2020-10-26 | 2020-12-18 |  | 2020-10-26 | 2020-12-18 | 40d |  |
| 23 | 2.6 | **Estudos Hidrológicos** |  | 10d | 2020-10-26 | 2020-11-06 |  | 2020-10-26 | 2020-11-06 | 10d | 0d |
| 24 | 2.6.1 | Clima | manual | 10d | 2020-10-26 | 2020-11-06 |  | 2020-10-26 | 2020-11-06 | 10d |  |
| 25 | 2.6.2 | Pluviometria | manual | 10d | 2020-10-26 | 2020-11-06 |  | 2020-10-26 | 2020-11-06 | 10d |  |
| 26 | 2.6.3 | Fluviometria | manual | 10d | 2020-10-26 | 2020-11-06 |  | 2020-10-26 | 2020-11-06 | 10d |  |

| ID | WBS | Task | Type | Duration | Start | Finish | Predecessors | Baseline start | Baseline finish | Baseline duration | Total slack |
| --- | --- | --- | --- | --- | --- | --- | --- | --- | --- | --- | --- |
| 27 | 2.7 | **Drenagem Superficial e Obras de Arte Correntes** |  | 40d | 2020-10-27 | 2020-12-21 |  | 2020-10-27 | 2020-12-21 | 40d | 0d |
| 28 | 2.7.1 | Drenagem Superficial | manual | 40d | 2020-10-27 | 2020-12-21 |  | 2020-10-27 | 2020-12-21 | 40d |  |
| 29 | 2.7.2 | Obras de arte correntes - OAC | manual | 40d | 2020-10-27 | 2020-12-21 |  | 2020-10-27 | 2020-12-21 | 40d |  |
| 30 | 2.8 | **Obras de Arte Especiais** |  | 40d | 2020-10-27 | 2020-12-21 |  | 2020-10-27 | 2020-12-21 | 40d | 0d |
| 31 | 2.8.1 | Implantação de Pontes e Viadutos | manual | 40d | 2020-10-27 | 2020-12-21 |  | 2020-10-27 | 2020-12-21 | 40d |  |
| 32 | 2.9 | Faixa de Domínio | manual | 5d | 2020-12-15 | 2020-12-21 | 18 | 2020-12-15 | 2020-12-21 | 5d |  |
| 33 | 2.10 | Superestrutura | manual | 1d | 2020-12-15 | 2020-12-15 | 18 | 2020-12-15 | 2020-12-15 | 1d |  |
| 34 | 2.11 | Centro de Controle Operacional – CCO | manual | 1d | 2020-12-15 | 2020-12-15 | 18 | 2020-12-15 | 2020-12-15 | 1d |  |
| 35 | 2.12 | Sinalização | manual | 3d | 2020-12-15 | 2020-12-17 | 18 | 2020-12-15 | 2020-12-17 | 3d |  |
| 36 | 2.13 | **Interferências e obras complementares** |  | 35d | 2020-10-27 | 2020-12-14 |  | 2020-10-27 | 2020-12-14 | 35d | 0d |
| 37 | 2.13.1 | Cercas e Muros | manual | 3d | 2020-11-03 | 2020-11-05 | 11SS+5d | 2020-11-03 | 2020-11-05 | 3d |  |
| 38 | 2.13.2 | Estradas de Serviço | manual | 35d | 2020-10-27 | 2020-12-14 |  | 2020-10-27 | 2020-12-14 | 35d |  |
| 39 | 2.13.3 | Fibra Ótica Subterrânea | manual | 35d | 2020-10-27 | 2020-12-14 |  | 2020-10-27 | 2020-12-14 | 35d |  |
| 40 | 2.14 | Canteiro de Obras e Instalações | manual | 1d | 2020-12-15 | 2020-12-15 | 18 | 2020-12-15 | 2020-12-15 | 1d |  |
| 41 | 2.15 | **Mobilização e Desmobilização** |  | 1d | 2020-12-15 | 2020-12-15 |  | 2020-12-15 | 2020-12-15 | 1d | 0d |
| 42 | 2.15.1 | Estimativa da força de trabalho a ser deslocada | manual | 1d | 2020-12-15 | 2020-12-15 | 18 | 2020-12-15 | 2020-12-15 | 1d |  |
| 43 | 2.15.2 | Custo de mobilização de equipamentos | manual | 1d | 2020-12-15 | 2020-12-15 | 18 | 2020-12-15 | 2020-12-15 | 1d |  |
| 44 | 2.16 | Administração local da obra | manual | 1d | 2020-12-15 | 2020-12-15 | 18 | 2020-12-15 | 2020-12-15 | 1d |  |
| 45 | 2.17 | Oficina Mecânica | manual | 1d | 2020-12-15 | 2020-12-15 | 18 | 2020-12-15 | 2020-12-15 | 1d |  |
| 46 | 2.18 | Equipamentos Ferroviários | manual | 1d | 2020-12-15 | 2020-12-15 | 18 | 2020-12-15 | 2020-12-15 | 1d |  |
| 47 | 2.19 | Resumo da Alternativa | manual | 1d | 2020-12-15 | 2020-12-15 | 18 | 2020-12-15 | 2020-12-15 | 1d |  |
| 48 | 2.20 | Anexos | manual | 1d | 2020-12-15 | 2020-12-15 | 18 | 2020-12-15 | 2020-12-15 | 1d |  |
| 49 | 2.21 | Planilha de Custo – Volume 3 | manual | 3d | 2020-12-15 | 2020-12-17 | 18 | 2020-12-15 | 2020-12-17 | 3d |  |
